Schedule from MS Project, 2025-12-27 to 2026-06-21, status date 2026-06-14, costs in IRR, A marks actual dates.

## Calendars

- Standard: Mon-Wed 08:00-12:00, 13:00-17:00; Thu-Fri off; Sat-Sun 08:00-12:00, 13:00-17:00. Exceptions (off unless hours are given): 2026-01-03, 2026-01-17, 2026-02-04, 2026-02-11, 2026-03-11, 2026-03-21 to 2026-03-24, 2026-04-01 to 2026-04-02, 2026-04-14, 2026-05-28, 2026-06-04.

## Schedule

| ID | WBS | Task | Type | Duration | Start | Finish | Predecessors | Complete | Remaining | Total slack | Cost | Actual cost | شروع | پایان |
| --- | --- | --- | --- | --- | --- | --- | --- | --- | --- | --- | --- | --- | --- | --- |
| 1 | 1 | **خدمات مهندسی احداث خط 20 کیلوولت اختصاصی و توسعه پست 66/20 کیلوولت فوق توزیع بالادست نیروگاه خورشیدی نی ریز** |  | 116d | 2025-12-27 A | 2026-06-21 |  | 99% | 1.44d | 0d | 6,000,000,000 | 5,978,745,000 | 1404/10/6 | 1405/3/31 |
| 2 | 1.1 | شروع | milestone | 0d | 2025-12-27 A | 2025-12-27 A |  | 100% |  |  |  |  | 1404/10/6 | 1404/10/6 |
| 3 | 1.2 | **خدمات برنامه ریزی و کنترل پروژه‌ها** |  | 103d | 2025-12-27 A | 2026-06-02 |  | 99% | 0d | 0d | 85,000,000 | 84,745,000 | 1404/10/6 | 1405/3/12 |
| 4 | 1.2.1 | Master Document List |  | 93d | 2025-12-27 A | 2026-05-19 | 2SS | 99% | 0d | 0d | 25,500,000 | 25,245,000 | 1404/10/6 | 1405/2/29 |
| 5 | 1.2.2 | WBS |  | 5d | 2026-05-20 A | 2026-05-26 A | 4 | 100% |  |  | 34,000,000 | 34,000,000 | 1405/2/30 | 1405/3/5 |
| 6 | 1.2.3 | Time Schedule |  | 10d | 2026-05-20 A | 2026-06-02 A | 5SS | 100% |  |  | 25,500,000 | 25,500,000 | 1405/2/30 | 1405/3/12 |
| 7 | 1.3 | **مسیریابی و نقشه برداری** |  | 35d | 2025-12-27 A | 2026-02-17 A |  | 100% |  |  | 3,030,000,000 | 3,030,000,000 | 1404/10/6 | 1404/11/28 |
| 8 | 1.3.1 | بازدید از مسیر و تعیین زوایای مسیر جهت تهیه گزارش مسیر یابی |  | 32d | 2025-12-27 A | 2026-02-14 A | 2SS | 100% |  |  | 150,000,000 | 150,000,000 | 1404/10/6 | 1404/11/25 |
| 9 | 1.3.2 | انجام نقشه برداری مسیر نهایی خط در مسیرهای دشت |  | 2d | 2026-02-15 A | 2026-02-16 A | 8 | 100% |  |  | 1,710,000,000 | 1,710,000,000 | 1404/11/26 | 1404/11/27 |
| 10 | 1.3.3 | تهیه و ترسیم نقشه های پلان – پروفیل |  | 1d | 2026-02-17 A | 2026-02-17 A | 9 | 100% |  |  | 1,170,000,000 | 1,170,000,000 | 1404/11/28 | 1404/11/28 |
| 11 | 1.4 | **طراحی خط انتقال** |  | 80d | 2025-12-27 A | 2026-05-02 A |  | 100% |  |  | 1,470,000,000 | 1,470,000,000 | 1404/10/6 | 1405/2/12 |
| 12 | 1.4.1 | انجام محاسبات و طراحی پروژه و تهیه گزارش طراحی الکتریکی مربوطه |  | 34d | 2025-12-27 A | 2026-02-16 A | 8SS | 100% |  |  | 200,000,000 | 200,000,000 | 1404/10/6 | 1404/11/27 |
| 13 | 1.4.2 | بررسی های اولیه شرایط اقلیمی ، جمع آوری و آنالیز اطلاعات هواشناسی منطقه و تعيين نوع بارگذاري منطقه احداث خط انتقال |  | 34d | 2025-12-27 A | 2026-02-16 A | 12SS | 100% |  |  | 160,000,000 | 160,000,000 | 1404/10/6 | 1404/11/27 |
| 14 | 1.4.3 | بررسی و تهیه دفترچه محاسبات مکانیکی پروژه |  | 34d | 2025-12-27 A | 2026-02-16 A | 13SS | 100% |  |  | 180,000,000 | 180,000,000 | 1404/10/6 | 1404/11/27 |
| 15 | 1.4.4 | برج گذاری و تهیه نقشه های پلان و پروفیل برج گذاری شده |  | 6d | 2026-02-17 A | 2026-02-24 A | 10SS, 12SS+5d, 13SS, 14SS | 100% |  |  | 450,000,000 | 450,000,000 | 1404/11/28 | 1404/12/5 |
| 16 | 1.4.5 | بررسی و تهیه دفترچه محاسبات ایزولاسیون |  | 6d | 2026-02-17 A | 2026-02-24 A | 15SS | 100% |  |  | 150,000,000 | 150,000,000 | 1404/11/28 | 1404/12/5 |
| 17 | 1.4.6 | تهیه جداول مقادیر تجهیزات و دفترچه اطلاعات فنی تجهیزات |  | 40d | 2026-02-25 A | 2026-05-02 A | 16 | 100% |  |  | 150,000,000 | 150,000,000 | 1404/12/6 | 1405/2/12 |
| 18 | 1.4.7 | تهیه، هماهنگی و اخذ تاییدیه از کارفرما جهت اسناد مناقصه شامل جلد بازرگانی و جلد مشخصات فنی و نقشه ها برای کلیه مناقصاتی که توسط کارفرما تعیین می گردد . |  | 40d | 2026-02-25 A | 2026-05-02 A | 17SS | 100% |  |  | 180,000,000 | 180,000,000 | 1404/12/6 | 1405/2/12 |
| 19 | 1.5 | **مذاکرات قراردادی** |  | 36d | 2026-05-03 A | 2026-06-21 |  | 86% | 5d | 0d | 150,000,000 | 129,000,000 | 1405/2/13 | 1405/3/31 |
| 20 | 1.5.1 | شرکت در جلسات گشایش پیشنهادها و بررسی پیشنهادهای فنی – مالی پیشنهادات شرکت کنندگان در مناقصه و ارائه گزارش به کارفرما |  | 36d | 2026-05-03 A | 2026-06-21 | 18 | 86% | 5d | 0d | 100,000,000 | 86,000,000 | 1405/2/13 | 1405/3/31 |
| 21 | 1.5.2 | انجام مذاکرات قراردادی و تهیه و تنظیم اسناد قرارداد با برنده مناقصه ها ( سازندگان تجهیزات و پیمانکاران نصب ) به تعداد نسخ مورد نیاز‏ |  | 36d | 2026-05-03 A | 2026-06-21 | 20SS | 86% | 5d | 0d | 50,000,000 | 43,000,000 | 1405/2/13 | 1405/3/31 |
| 22 | 1.6 | **بازدید و بررسی فنی سوئیچگیر 20 کیلوولت پست 66/20 کیلوولت دانشگاه آزاد نیریز** |  | 86d | 2025-12-27 A | 2026-05-10 A |  | 100% |  |  | 500,000,000 | 500,000,000 | 1404/10/6 | 1405/2/20 |
| 23 | 1.6.1 | Substation Site Visit Report |  | 86d | 2025-12-27 A | 2026-05-10 A | 2SS | 100% |  |  | 500,000,000 | 500,000,000 | 1404/10/6 | 1405/2/20 |
| 24 | 1.7 | **خدمات مهندسی** |  | 99d | 2025-12-27 A | 2026-05-27 A |  | 100% |  |  | 765,000,000 | 765,000,000 | 1404/10/6 | 1405/3/6 |
| 25 | 1.7.1 | Basic Drawing |  | 85d | 2025-12-27 A | 2026-05-09 A | 2 | 100% |  |  | 212,500,000 | 212,500,000 | 1404/10/6 | 1405/2/19 |
| 26 | 1.7.2 | Summary Of Works |  | 20d | 2025-12-27 A | 2026-01-25 A | 25SS | 100% |  |  | 34,000,000 | 34,000,000 | 1404/10/6 | 1404/11/5 |
| 27 | 1.7.3 | General Requirements |  | 20d | 2026-01-26 A | 2026-02-24 A | 26 | 100% |  |  | 34,000,000 | 34,000,000 | 1404/11/6 | 1404/12/5 |
| 28 | 1.7.4 | Specification For Medium Voltage Switchgear |  | 20d | 2026-02-25 A | 2026-03-31 A | 27 | 100% |  |  | 34,000,000 | 34,000,000 | 1404/12/6 | 1405/1/11 |
| 29 | 1.7.5 | Specification For Cable System |  | 20d | 2026-02-25 A | 2026-03-31 A | 28SS | 100% |  |  | 34,000,000 | 34,000,000 | 1404/12/6 | 1405/1/11 |
| 30 | 1.7.6 | Specification For Grounding System |  | 20d | 2026-02-25 A | 2026-03-31 A | 29SS | 100% |  |  | 34,000,000 | 34,000,000 | 1404/12/6 | 1405/1/11 |
| 31 | 1.7.7 | Specification For Control And Protection |  | 20d | 2026-02-25 A | 2026-03-31 A | 30SS | 100% |  |  | 34,000,000 | 34,000,000 | 1404/12/6 | 1405/1/11 |
| 32 | 1.7.8 | Guarantee Table For Medium Voltage Switchgear |  | 25d | 2026-04-04 A | 2026-05-09 A | 31 | 100% |  |  | 34,000,000 | 34,000,000 | 1405/1/15 | 1405/2/19 |
| 33 | 1.7.9 | Guarantee Table For Cable System |  | 25d | 2026-04-04 A | 2026-05-09 A | 32SS | 100% |  |  | 34,000,000 | 34,000,000 | 1405/1/15 | 1405/2/19 |
| 34 | 1.7.10 | Guarantee Table For Grounding System |  | 25d | 2026-04-04 A | 2026-05-09 A | 33SS | 100% |  |  | 34,000,000 | 34,000,000 | 1405/1/15 | 1405/2/19 |
| 35 | 1.7.11 | Guarantee Table For Control And Protection |  | 25d | 2026-04-04 A | 2026-05-09 A | 34SS | 100% |  |  | 34,000,000 | 34,000,000 | 1405/1/15 | 1405/2/19 |
| 36 | 1.7.12 | Price List |  | 7d | 2026-05-19 A | 2026-05-27 A | 35FS+7d, 23 | 100% |  |  | 212,500,000 | 212,500,000 | 1405/2/29 | 1405/3/6 |
| 37 | 1.8 | پایان | milestone | 0d | 2026-06-21 | 2026-06-21 | 6, 21, 36 |  |  | 0d |  |  | 1405/3/31 | 1405/3/31 |
